# De install DVCS in Dec. 2015- install Tritium in spring 16

Schedule from MS Project, 2016-04-11 to 2017-02-08.
JLAB

## Calendars

- Standard: Mon-Fri 08:00-12:00, 13:00-17:00; Sat-Sun off. Exceptions (off unless hours are given): 2016-05-30 (Nonworking), 2016-07-04 (Nonworking), 2016-09-05 (Nonworking), 2016-11-24 to 2016-11-25 (Nonworking), 2016-12-23 to 2017-01-02 (Nonworking).

## Resources

| Resource |
| --- |
| Folts |
| Physics electronics group |
| Lumanog |
| Segal |
| Smith |
| Fansler |
| Ewing |
| ELECTRICIAN (TECH) |
| MECH ALIGN TECH |
| PLANT ENG |
| MECH INST TECH LITE |
| MECH VAC TECH |
| MSHOP |
| H-A MECH DES |
| ICD ELEC TECH |
| H-A MECH TECH |
| TARGET GROUP TECH |
| RADCON TECH |
| CRYO MECH ENG |
| Butler |
| Experimenters |
| OPS SOFTWARE |

## Schedule

| ID | WBS | Task | Duration | Start | Finish | Predecessors | Total slack | Free slack |
| --- | --- | --- | --- | --- | --- | --- | --- | --- |
| 1 | 1 | **DVCS to Tritium** | 206d | 2016-04-11 | 2017-02-08 |  | 0d |  |
| 2 | 1.1 | **Summer 2016** | 123d | 2016-04-11 | 2016-10-03 |  | 0d |  |
| 3 | 1.1.1 | **Hall Infrastructure Improvements** | 123d | 2016-04-11 | 2016-10-03 |  | 0d |  |
| 4 | 1.1.1.1 | **Preliminaries** | 63d | 2016-04-11 | 2016-07-08 |  | 0d |  |
| 5 | 1.1.1.1.1 | Post run surveys and checklist | 1d | 2016-04-11 | 2016-04-11 |  | 0d |  |
| 6 | 1.1.1.1.2 | RADCON hold for target, beam lines and pivot area | 2d | 2016-04-12 | 2016-04-13 | 5 | 0d |  |
| 7 | 1.1.1.1.3 | Begin Bleeding up both HRS | 15d | 2016-04-14 | 2016-05-04 | 6 | 188d |  |
| 8 | 1.1.1.1.4 | Bleed up all beam lines and spectrometers | 2d | 2016-04-14 | 2016-04-15 | 6 | 0d |  |
| 9 | 1.1.1.1.5 | Fabricate new water manifold above pivot | 15d | 2016-04-18 | 2016-05-06 | 8 | 0d |  |
| 10 | 1.1.1.1.6 | Install conventional quad LCW lines | 3d | 2016-05-09 | 2016-05-11 | 9 | 0d |  |
| 11 | 1.1.1.1.7 | Install conventional quad current leads | 2d | 2016-05-12 | 2016-05-13 | 10 | 0d |  |
| 12 | 1.1.1.1.8 | Install conventional power supplies | 2d | 2016-05-16 | 2016-05-17 | 11 | 0d |  |
| 13 | 1.1.1.1.9 | Connect power, LCW and interlocks for power supply | 3d | 2016-05-18 | 2016-05-20 | 12 | 3d | 0d |
| 14 | 1.1.1.1.10 | Local test power supply using dummy load | 5d | 2016-05-23 | 2016-05-27 | 13 | 3d | 0d |
| 15 | 1.1.1.1.11 | Write GUI for remote control | 28d | 2016-05-31 | 2016-07-08 | 14 | 3d |  |
| 16 | 1.1.1.2 | **Right HRS** | 22d | 2016-04-18 | 2016-05-17 |  | 179d |  |
| 17 | 1.1.1.2.1 | Remove enterance window and external sieve | 1d | 2016-04-18 | 2016-04-18 | 8 | 179d | 0d |
| 18 | 1.1.1.2.2 | Disconnect beam pipe between Q1 & Q2 | 1d | 2016-04-19 | 2016-04-19 | 17 | 179d | 0d |
| 19 | 1.1.1.2.3 | Disconnect LCW | 1d | 2016-04-20 | 2016-04-20 | 18 | 179d | 0d |
| 20 | 1.1.1.2.4 | Remove guards and disconnect current leads and interlocks | 1d | 2016-04-21 | 2016-04-21 | 19 | 179d | 0d |
| 21 | 1.1.1.2.5 | Rig and prep resistive Q1 for removal | 2d | 2016-04-22 | 2016-04-25 | 20 | 179d | 0d |
| 22 | 1.1.1.2.6 | Remove resistive Q1 from Right HRS | 1d | 2016-04-26 | 2016-04-26 | 21 | 179d | 0d |
| 23 | 1.1.1.2.7 | Install new magnet mount | 2d | 2016-04-27 | 2016-04-28 | 22 | 179d | 0d |
| 24 | 1.1.1.2.8 | Re-attach resistive Q1 to Right HRS | 1d | 2016-04-29 | 2016-04-29 | 23 | 179d | 0d |
| 25 | 1.1.1.2.9 | Use lasers to align (Techs) | 2d | 2016-05-02 | 2016-05-03 | 24 | 179d | 0d |
| 26 | 1.1.1.2.10 | Re-connect current leads and interlock | 2d | 2016-05-04 | 2016-05-05 | 25 | 179d | 0d |
| 27 | 1.1.1.2.11 | Re-connect LCW | 1d | 2016-05-06 | 2016-05-06 | 26 | 179d | 0d |
| 28 | 1.1.1.2.12 | Conduct startup test to verify controls and interlocks interlocks | 3d | 2016-05-09 | 2016-05-11 | 27 | 179d | 0d |
| 29 | 1.1.1.2.13 | Re-connect beam pipe between Q1 & Q2. | 1d | 2016-05-12 | 2016-05-12 | 28 | 179d | 0d |
| 30 | 1.1.1.2.14 | Re-install enterance window | 1d | 2016-05-13 | 2016-05-13 | 29 | 179d | 0d |
| 31 | 1.1.1.2.15 | Pull Right HRS under vacuum and leak check | 2d | 2016-05-16 | 2016-05-17 | 30 | 179d |  |

Notes:
- 9: We may need to solicit the help of Hall C techs to carry out this task. Our current LCW capacity at the pivot will not support two resistive magnets and Big Bite.
- 10: LCW lines will need to ran from the fabricated manifold, across the pivot and on to each of the resistive magnets.
- 11: New current leads will need to be ran for both resistive magnets. The RQ1 is currently using our Big Bite power supply which will require being re-done when the Big Bite magnet is needed. Idealy we can install the new Q1 power supplies on the power supply platform and reuse the current leads from the cryogentic Q1s; if so, we can also use the LCW on the power supply platform.
- 12: Investigate whether or not these power supplies be installed on the PS balcony and use existing power and water???
- 15: Written by someone from Software Group with input from technicians

| ID | WBS | Task | Duration | Start | Finish | Predecessors | Total slack |
| --- | --- | --- | --- | --- | --- | --- | --- |
| 32 | 1.1.1.3 | **Left HRS** | 46d | 2016-05-18 | 2016-07-22 |  | 0d |
| 33 | 1.1.1.3.1 | Warm-up Q1 magnet | 5d | 2016-05-18 | 2016-05-24 | 12 | 0d |
| 34 | 1.1.1.3.2 | De-sting U-Tubes | 1d | 2016-05-25 | 2016-05-25 | 33 | 0d |
| 35 | 1.1.1.3.3 | Disconnect Q1 from warm return | 1d | 2016-05-26 | 2016-05-26 | 34 | 0d |
| 36 | 1.1.1.3.4 | Disconnect and remove Q1 lead flows | 1d | 2016-05-27 | 2016-05-27 | 35 | 0d |
| 37 | 1.1.1.3.5 | Disconnect and label Q1 current leads and electronics | 2d | 2016-05-31 | 2016-06-01 | 36 | 0d |
| 38 | 1.1.1.3.6 | Rig and prep magnet for removal | 3d | 2016-06-02 | 2016-06-06 | 37 | 0d |
| 39 | 1.1.1.3.7 | Remove cryogenic Q1 from L- HRS | 1d | 2016-06-07 | 2016-06-07 | 38 | 0d |
| 40 | 1.1.1.3.8 | Move cryogenic Q1 into storage | 1d | 2016-06-08 | 2016-06-08 | 39 | 0d |
| 41 | 1.1.1.3.9 | Assemble new resistive magnet | 5d | 2016-06-09 | 2016-06-15 | 40 | 0d |
| 42 | 1.1.1.3.10 | Install new magnet mounts | 1d | 2016-06-16 | 2016-06-16 | 41 | 0d |
| 43 | 1.1.1.3.11 | Rig and prep for installation | 1d | 2016-06-17 | 2016-06-17 | 42 | 0d |
| 44 | 1.1.1.3.12 | Attach resistive Q1 to Left HRS | 1d | 2016-06-20 | 2016-06-20 | 43 | 0d |
| 45 | 1.1.1.3.13 | Use lasers to align (Techs) | 3d | 2016-06-21 | 2016-06-23 | 44 | 0d |
| 46 | 1.1.1.3.14 | Connect current leads and interlocks | 1d | 2016-06-24 | 2016-06-24 | 45 | 0d |
| 47 | 1.1.1.3.15 | Connect LCW | 1d | 2016-06-27 | 2016-06-27 | 46 | 0d |
| 48 | 1.1.1.3.16 | Conduct startup test to verify controls and interlocks | 4d | 2016-06-28 | 2016-07-01 | 47 | 0d |
| 49 | 1.1.1.3.17 | Connect beam pipe between Q1 & Q2 | 1d | 2016-07-05 | 2016-07-05 | 48 | 0d |
| 50 | 1.1.1.3.18 | Install enterance window | 1d | 2016-07-06 | 2016-07-06 | 49 | 0d |
| 51 | 1.1.1.3.19 | Pull Left HRS under vacuum | 2d | 2016-07-07 | 2016-07-08 | 50 | 0d |
| 52 | 1.1.1.3.20 | Final Survey & Alignment | 3d | 2016-07-11 | 2016-07-13 | 51 | 0d |
| 53 | 1.1.1.3.21 | Test GUI, magnet and power supply funtionality | 7d | 2016-07-14 | 2016-07-22 | 52, 15 | 0d |
| 54 | 1.1.1.4 | **Final Preparations** | 50d | 2016-07-25 | 2016-10-03 |  | 0d |
| 55 | 1.1.1.4.1 | Cryogenic magnets cool-down | 25d | 2016-07-25 | 2016-08-26 | 53 | 0d |
| 56 | 1.1.1.4.2 | Magnet/Power Supply startup and test | 15d | 2016-08-29 | 2016-09-19 | 55 | 0d |
| 57 | 1.1.1.4.3 | Final Survey & Alignment | 5d | 2016-09-20 | 2016-09-26 | 56 | 0d |
| 58 | 1.1.1.4.4 | Hall cleanup | 4d | 2016-09-27 | 2016-09-30 | 57 | 0d |
| 59 | 1.1.1.4.5 | Pre-beam cheacklist | 1d | 2016-10-03 | 2016-10-03 | 58 | 83d |
| 60 | 1.1.1.4.6 | Vaccum & Helium leak checks and system clean-up | 40d | 2016-07-25 | 2016-09-19 | 53 | 93d |
| 61 | 1.1.1.4.7 | System change documentation | 40d | 2016-07-25 | 2016-09-19 | 53 | 93d |

Notes:
- 33: This task may get pushed to the right. The idea time to remove the LQ1 would be "upon receiving shipping confirmation" and JLAB has an ETA for the new magnet.
- 41: This task involvesputting the magnet together as well as welding in the associated beam pipe

| ID | WBS | Task | Duration | Start | Finish | Predecessors | Total slack | Free slack |
| --- | --- | --- | --- | --- | --- | --- | --- | --- |
| 62 | 1.2 | **Beam Time** | 57d | 2016-10-03 | 2016-12-22 |  | 0d |  |
| 63 | 1.2.1 | DVCS Experiment | 57d | 2016-10-03 | 2016-12-22 | 58 | 0d |  |
| 64 | 1.3 | **Winter 2016** | 27d | 2017-01-03 | 2017-02-08 |  | 0d |  |
| 65 | 1.3.1 | **De-Installation of DVCS Equipment** | 23d | 2017-01-03 | 2017-02-02 | 63 | 4d |  |
| 66 | 1.3.1.1 | **Preliminaries** | 12d | 2017-01-03 | 2017-01-18 |  | 15d |  |
| 67 | 1.3.1.1.1 | Post run surveys and checklist | 1d | 2017-01-03 | 2017-01-03 |  | 24d | 0d |
| 68 | 1.3.1.1.2 | RADCON hold for target, beam lines and pivot area | 2d | 2017-01-04 | 2017-01-05 | 67 | 24d |  |
| 69 | 1.3.1.1.3 | Post run checklist | 1d | 2017-01-03 | 2017-01-03 |  | 15d | 0d |
| 70 | 1.3.1.1.4 | Bleed up all beam lines and spectrometers | 1d | 2017-01-04 | 2017-01-04 | 69 | 15d | 0d |
| 71 | 1.3.1.1.5 | Commence cryogenic system warm-up | 10d | 2017-01-05 | 2017-01-18 | 70 | 15d |  |
| 72 | 1.3.1.2 | **Remove Calorimeter, Shielding & Stand** | 15d | 2017-01-03 | 2017-01-23 |  | 12d |  |
| 73 | 1.3.1.2.1 | Disconnect cables (detector and shield hut) | 2d | 2017-01-03 | 2017-01-04 |  | 12d | 0d |
| 74 | 1.3.1.2.2 | Remove crystals | 3d | 2017-01-05 | 2017-01-09 | 73 | 12d | 0d |
| 75 | 1.3.1.2.3 | Remove detector carriage | 1d | 2017-01-10 | 2017-01-10 | 74 | 12d | 0d |
| 76 | 1.3.1.2.4 | Remove detector stand | 1d | 2017-01-11 | 2017-01-11 | 75 | 12d | 0d |
| 77 | 1.3.1.2.5 | Remove detector support | 2d | 2017-01-12 | 2017-01-13 | 76 | 12d | 0d |
| 78 | 1.3.1.2.6 | Remove cables from shield house | 4d | 2017-01-16 | 2017-01-19 | 77 | 12d | 0d |
| 79 | 1.3.1.2.7 | Stow away cables and electronics | 2d | 2017-01-20 | 2017-01-23 | 78 | 12d |  |
| 80 | 1.3.1.3 | **Remove DVCS Target** | 10d | 2017-01-03 | 2017-01-16 |  | 17d |  |
| 81 | 1.3.1.3.1 | Target Group Scheduling | 10d | 2017-01-03 | 2017-01-16 |  | 17d |  |
| 82 | 1.3.1.4 | **Remove Moeller Target** | 23d | 2017-01-03 | 2017-02-02 |  | 4d |  |
| 83 | 1.3.1.4.1 | Power down and warm-up target | 2d | 2017-01-03 | 2017-01-04 |  | 4d | 0d |
| 84 | 1.3.1.4.2 | Bleed-up beamline | 1d | 2017-01-05 | 2017-01-05 | 83 | 4d | 0d |
| 85 | 1.3.1.4.3 | Disconnect instrumentation and beamline | 2d | 2017-01-06 | 2017-01-09 | 84 | 4d | 0d |
| 86 | 1.3.1.4.4 | Remove moeller target from beamline | 2d | 2017-01-10 | 2017-01-11 | 85 | 4d | 0d |
| 87 | 1.3.1.4.5 | Install new section of beamline | 3d | 2017-01-19 | 2017-01-23 | 86FS+5d | 4d | 0d |
| 88 | 1.3.1.4.6 | Pump down and leak check | 3d | 2017-01-31 | 2017-02-02 | 87FS+5d | 4d |  |

Notes:
- 71: This task will heavily depend on the need of the Spectrometer Support Group and the support of the Cryogenic Group. Ideally this task would start immediately but may shift depending on these two external factors.
- 81: This task will need approval from Target Group in the best interest to protect their target cells.

| ID | WBS | Task | Duration | Start | Finish | Predecessors | Total slack | Free slack | Constraint |
| --- | --- | --- | --- | --- | --- | --- | --- | --- | --- |
| 89 | 1.3.2 | **Installation of Tritium Equipment** | 27d | 2017-01-03 | 2017-02-08 |  | 0d |  |  |
| 90 | 1.3.2.1 | **Preliminaries** | 6d | 2017-01-03 | 2017-01-10 | 63 | 16d |  |  |
| 91 | 1.3.2.1.1 | Disconnect upstream beamline vacuum system | 1d | 2017-01-03 | 2017-01-03 | 44 | 16d | 0d |  |
| 92 | 1.3.2.1.2 | Disconnect downstream beamline vacuum system | 1d | 2017-01-04 | 2017-01-04 | 91 | 16d | 0d |  |
| 93 | 1.3.2.1.3 | Remove downstream extension and beam pipes | 1d | 2017-01-05 | 2017-01-05 | 92 | 16d | 0d |  |
| 94 | 1.3.2.1.4 | Modify target platform to support Tritium installation | 3d | 2017-01-06 | 2017-01-10 | 93 | 21d |  |  |
| 95 | 1.3.2.2 | **Target Chamber Setup** | 8d | 2017-01-06 | 2017-01-17 |  | 16d |  |  |
| 96 | 1.3.2.2.1 | Remove upper spool section of chamber | 1d | 2017-01-06 | 2017-01-06 | 93 | 16d | 0d |  |
| 97 | 1.3.2.2.2 | Rotate left spectrometer to 25 degrees | 1d | 2017-01-09 | 2017-01-09 | 96 | 16d | 0d |  |
| 98 | 1.3.2.2.3 | Rotate right spectrometer to 30 degrees | 1d | 2017-01-09 | 2017-01-09 | 96 | 16d | 0d |  |
| 99 | 1.3.2.2.4 | Rotate center section of chamber to large window opening downstream | 1d | 2017-01-10 | 2017-01-10 | 98, 97 | 16d | 0d |  |
| 100 | 1.3.2.2.5 | Install upper spool section | 1d | 2017-01-11 | 2017-01-11 | 99 | 16d | 0d |  |
| 101 | 1.3.2.2.6 | Re-connect vacuum system | 2d | 2017-01-12 | 2017-01-13 | 100 | 16d | 0d |  |
| 102 | 1.3.2.2.7 | Rough align target chamber (Hall-A Techs) | 1d | 2017-01-16 | 2017-01-16 | 101 | 16d | 0d |  |
| 103 | 1.3.2.2.8 | Install exit beam pipe | 1d | 2017-01-17 | 2017-01-17 | 102 | 16d |  |  |
| 104 | 1.3.2.3 | **Target & Target Platform Installation** | 25d | 2017-01-03 | 2017-02-06 |  | 2d |  |  |
| 105 | 1.3.2.3.1 | Target Group Scheduling | 25d | 2017-01-03 | 2017-02-06 | 63 | 2d |  |  |
| 106 | 1.3.2.4 | **Tritium Infrastructure & Support Systems** | 25d | 2017-01-05 | 2017-02-08 |  | 0d |  |  |
| 107 | 1.3.2.4.1 | Finish installing tritium exhaust and fan inside Hall | 10d | 2017-01-05 | 2017-01-18 | 63FS+2d | 0d |  |  |
| 108 | 1.3.2.4.2 | Finish installing tritium exhaust outside of Hall | 10d | 2017-01-19 | 2017-02-01 | 107 | 0d |  |  |
| 109 | 1.3.2.4.3 | Setup perimeter fence | 5d | 2017-02-02 | 2017-02-08 | 108 | 0d |  |  |
| 110 | 1.3.2.5 | **Final Preparations** | 11d | 2017-01-25 | 2017-02-08 |  | 0d |  |  |
| 111 | 1.3.2.5.1 | Magnet/Power Supply startup and test | 10d | 2017-01-25 | 2017-02-07 |  | 0d |  | as late as possible |
| 112 | 1.3.2.5.2 | Final Survey & Alignment | 5d | 2017-02-02 | 2017-02-08 |  | 0d |  | as late as possible |
| 113 | 1.3.2.5.3 | Hall cleanup | 4d | 2017-02-02 | 2017-02-07 |  | 0d |  | as late as possible |
| 114 | 1.3.2.5.4 | Pre-beam cheacklist | 1d | 2017-02-08 | 2017-02-08 | 113, 111 | 0d |  | as late as possible |
